# ГПР подкрановые пути

Schedule from MS Project, 2025-07-28 to 2025-12-12.

## Calendars

- Стандартный: Mon-Fri 09:00-13:00, 14:00-18:00; Sat-Sun off.

## Schedule

| ID | WBS | Task | Duration | Start | Finish | Predecessors | Total slack |
| --- | --- | --- | --- | --- | --- | --- | --- |
| 1 | 1 | **Монтаж подкрановых путей крытого склада №1 и №2** | 100d | 2025-07-28 | 2025-12-12 |  | 0d |
| 2 | 1.1 | Подготовка площадки и мобилизация | 5d | 2025-07-28 | 2025-08-01 |  | 0d |
| 3 | 1.2 | **Склад №1** | 42d | 2025-08-04 | 2025-09-30 |  | 0d |
| 4 | 1.2.1 | Геодезическая разбивка | 2d | 2025-08-04 | 2025-08-05 | 2 | 0d |
| 5 | 1.2.2 | Рельсовый путь № 1 (327 м) | 8d | 2025-08-06 | 2025-08-15 | 4 | 0d |
| 6 | 1.2.3 | Рельсовый путь № 2 (344 м) | 8d | 2025-08-18 | 2025-08-27 | 5 | 0d |
| 7 | 1.2.4 | Рельсовый путь № 3 (325 м) | 14d | 2025-08-28 | 2025-09-16 | 6 | 0d |
| 8 | 1.2.5 | Крепление опорных деталей | 7d | 2025-09-17 | 2025-09-25 | 7 | 0d |
| 9 | 1.2.6 | Исполнительная документация и сдача | 3d | 2025-09-26 | 2025-09-30 | 8 | 53d |
| 10 | 1.3 | **Склад №2** | 56d | 2025-09-26 | 2025-12-12 |  | 0d |
| 11 | 1.3.1 | Геодезическая разбивка | 2d | 2025-09-26 | 2025-09-29 | 8 | 0d |
| 12 | 1.3.2 | Рельсовый путь № 1 (387 м) | 13d | 2025-09-30 | 2025-10-16 | 11 | 0d |
| 13 | 1.3.3 | Рельсовый путь № 2 (405 м) | 13d | 2025-10-17 | 2025-11-04 | 12 | 0d |
| 14 | 1.3.4 | Рельсовый путь № 3 (386 м) | 18d | 2025-11-05 | 2025-11-28 | 13 | 0d |
| 15 | 1.3.5 | Крепление опорных деталей | 7d | 2025-12-01 | 2025-12-09 | 14 | 0d |
| 16 | 1.3.6 | Исполнительная документация и сдача | 3d | 2025-12-10 | 2025-12-12 | 15 | 0d |
